# 205b91

How a schedule from MS Project changed from version to version. A marks actual dates.

## Version 1 (data date 2002-12-06, saved 2007-06-14, file PRILOGA C- POGODBENI TERMINSKI PLANredvideno.mpp)

| ID | WBS | Task | Duration | Start | Finish | Predecessors | Total float | Constraint |
| --- | --- | --- | --- | --- | --- | --- | --- | --- |
| 1 |  | PRILOGA C: POGODBENI TERMINSKI PLAN | 1d? | 2005-09-26 | 2005-09-26 |  | 113d |  |
| 2 | 2 | **DVA VEČSTANOVANJSKA OBJEKTA V LJUBLJANI** | 117d | 2005-09-22 | 2006-02-15 |  | 0d |  |
| 3 | 2.1 | **OBJEKT 1** | 113d | 2005-09-22 | 2006-02-10 |  | 4d |  |
| 4 | 2.1.1 | **PRIPRAVLJALNA DELA** | 10d | 2005-09-22 | 2005-10-03 |  | 107d |  |
| 5 |  | Priprava gradbišča, postavitev ograj, kontej.skladišč, strojev, ured. dovoza | 7d | 2005-09-22 | 2005-09-29 |  | 218d | start no earlier than 2005-09-22 |
| 6 |  | Odriv humusa, široki izkop,odvoz na deponijo,planiranje dna gradbene jame | 7d | 2005-09-26 | 2005-10-03 | 5SS+3d | 218d | finish no earlier than 2005-05-19 |
| 7 | 2.1.2 | **TEMELJI** | 15d | 2005-10-03 | 2005-10-19 |  | 93d |  |
| 8 |  | Izkop za temelje | 3d | 2005-10-03 | 2005-10-05 |  | 212d | start no earlier than 2005-10-02 |
| 9 |  | Podložni beton pod temelji | 6d | 2005-10-04 | 2005-10-10 | 8SS+1d | 212d | finish no earlier than 2004-12-08 |
| 10 |  | Izdelava temeljev točkovnih in pasovnih, zasip za temelji | 12d | 2005-10-05 | 2005-10-18 | 9SS+1d | 202d | start no earlier than 2005-01-17 |
| 11 |  | vgrajevanje tampona z utrjevanjem | 10d | 2005-10-08 | 2005-10-19 | 10SS+3d | 203d | start no earlier than 2005-05-16 |
| 12 |  | KANALIZACIJA notranja, kinete, zasip | 10d | 2005-10-10 | 2005-10-20 | 11SS+1d | 203d |  |
| 13 |  | TALNA PLOŠČA | 10d | 2005-10-11 | 2005-10-21 | 10SS+5d | 202d | start no earlier than 2005-03-14 |
| 14 | 2.1.5 | **PRITLIČJE** | 14d | 2005-10-17 | 2005-11-03 |  | 66d |  |
| 15 |  | ab stene, stebri, vertikalne vezi | 9d | 2005-10-17 | 2005-10-26 |  | 134d | start no earlier than 2005-10-17 |
| 16 |  | zidanje zidov | 9d | 2005-10-17 | 2005-10-26 | 15SS | 198d | start no earlier than 2005-06-18 |
| 17 |  | horizontalne vezi, preklade, pošča | 8d | 2005-10-24 | 2005-11-03 | 15FS-3d | 134d | start no earlier than 2005-06-29 |
| 18 | 2.1.6 | **1. ETAŽA** | 15d | 2005-10-29 | 2005-11-17 |  | 66d |  |
| 19 |  | ab stene, stebri, vertikalne vezi | 9d | 2005-10-29 | 2005-11-10 | 17FS-3d | 134d |  |
| 20 |  | zidanje zidov | 9d | 2005-10-29 | 2005-11-10 | 19SS | 187d | start no earlier than 2005-06-18 |
| 21 |  | horizontalne vezi, preklade, pošča | 8d | 2005-11-09 | 2005-11-17 | 19FS-2d | 134d |  |
| 22 |  | VENEC NA STREHI | 6d | 2005-11-16 | 2005-11-22 | 21FS-2d | 134d |  |
| 23 |  | Predelne stene | 36d | 2005-12-23 | 2006-02-10 |  | 115d | start no earlier than 2005-12-23 |
| 24 | 2.2 | **OBJEKT 2** | 105d | 2005-10-06 | 2006-02-15 |  | 0d |  |
| 25 | 2.2.1 | **TEMELJI** | 15d | 2005-10-06 | 2005-10-22 |  | 15d |  |
| 26 |  | Izkop za temelje | 3d | 2005-10-06 | 2005-10-08 |  | 98d | start no earlier than 2005-10-06 |
| 27 |  | Podložni beton pod temelji | 6d | 2005-10-07 | 2005-10-13 | 26FS-2d | 98d | finish no earlier than 2004-12-08 |
| 28 |  | Izdelava temeljev točkovnih in pasovnih, zasip za temelji | 12d | 2005-10-08 | 2005-10-21 | 27SS+1d | 13d | start no earlier than 2005-01-17 |
| 29 |  | vgrajevanje tampona z utrjevanjem | 10d | 2005-10-12 | 2005-10-22 | 28SS+3d | 89d | start no earlier than 2005-05-16 |
| 30 |  | KANALIZACIJA notranja, kinete, zasip | 10d | 2005-10-13 | 2005-10-24 | 29SS+1d | 89d |  |
| 31 |  | TALNA PLOŠČA | 10d | 2005-10-14 | 2005-10-25 | 28SS+5d | 13d | start no earlier than 2005-03-14 |
| 32 | 2.2.4 | **PRITLIČJE** | 15d | 2005-10-26 | 2005-11-14 |  | 13d |  |
| 33 |  | ab stene, stebri, vertikalne vezi | 10d | 2005-10-26 | 2005-11-08 | 31 | 13d | start no earlier than 2005-10-17 |
| 34 |  | zidanje zidov | 9d | 2005-10-26 | 2005-11-07 | 33SS | 79d | start no earlier than 2005-06-18 |
| 35 |  | horizontalne vezi, preklade, pošča | 8d | 2005-11-05 | 2005-11-14 | 33FS-3d | 13d | start no earlier than 2005-06-29 |
| 36 | 2.2.5 | **1. ETAŽA** | 59d | 2005-11-11 | 2006-01-26 |  | 13d |  |
| 37 |  | ab stene, stebri, vertikalne vezi | 9d | 2005-11-11 | 2005-11-21 | 35FS-3d | 13d |  |
| 38 |  | zidanje zidov | 9d | 2005-11-11 | 2005-11-21 | 37SS | 67d | start no earlier than 2005-06-18 |
| 39 |  | horizontalne vezi, preklade, pošča | 8d | 2005-11-19 | 2006-01-26 | 37FS-2d | 13d |  |
| 40 |  | VENEC NA STREHI | 6d | 2006-01-31 | 2006-02-06 | 39FS-2d | 8d | start no earlier than 2006-01-31 |
| 41 |  | Predelne stene | 27d | 2006-01-16 | 2006-02-15 |  | 0d | start no earlier than 2006-01-16 |

## Version 2 (data date 2002-12-06, saved 2007-06-14, file PRILOGA D -PRIMERJAVA PLANIRANEGA IN DEJANSKO IZVEDENEGA DEL.mpp)

Last finish 2006-02-15 → 2006-02-22 (+7d). Complete tasks 0 → 30.

Changed:

| ID | Task | Start | Finish | Duration | Complete | Total float | Other |
| --- | --- | --- | --- | --- | --- | --- | --- |
| 1 | PRILOGA D: PRIMERJAVA PLANIRANEGA IN DEJANSKO IZVEDENEGA DELA |  |  |  |  | 113d → 117d | was named PRILOGA C: POGODBENI TERMINSKI PLAN |
| 2 | **DVA VEČSTANOVANJSKA OBJEKTA V LJUBLJANI** | 2005-09-22 A | 2006-02-15 → 2006-02-22 A (+7d) | 117d → 119.25d | 0% → 100% | 0d → none | baseline start none → 2005-09-22; baseline finish none → 2006-02-15 |
| 3 | **OBJEKT 1** | 2005-09-22 A | 2006-02-10 → 2006-02-03 A (-7d) | 113d → 103.25d | 0% → 100% | 4d → none | baseline start none → 2005-09-22; baseline finish none → 2006-02-10 |
| 4 | **PRIPRAVLJALNA DELA** | 2005-09-22 A | 2005-10-03 → 2005-10-05 A (+2d) | 10d → 9d | 0% → 100% | 107d → none | baseline start none → 2005-09-22; baseline finish none → 2005-10-03 |
| 5 | Priprava gradbišča, postavitev ograj, kontej.skladišč, strojev, ured. Dovoza | 2005-09-22 A | 2005-09-29 → 2005-10-05 A (+6d) | 7d → 9d | 0% → 100% | 218d → none | was named Priprava gradbišča, postavitev ograj, kontej.skladišč, strojev, ured. dovoza; constraint start no earlier than 2005-09-22 → finish no earlier than 2005-10-04; baseline start none → 2005-09-22; baseline finish none → 2005-09-29 |
| 6 | Odriv humusa, široki izkop,odvoz na deponijo,planiranje dna gradbene jame | 2005-09-26 → 2005-10-05 A (+9d) | 2005-10-03 → 2005-10-05 A (+2d) | 7d → 0d | 0% → 100% | 218d → none | constraint finish no earlier than 2005-05-19 → start no earlier than 2005-10-04; baseline start none → 2005-09-26; baseline finish none → 2005-10-03 |
| 7 | **TEMELJI** | 2005-10-03 → 2005-10-06 A (+3d) | 2005-10-19 A | 15d → 12d | 0% → 100% | 93d → none | baseline start none → 2005-10-03; baseline finish none → 2005-10-19 |
| 8 | Izkop za temelje | 2005-10-03 → 2005-10-06 A (+3d) | 2005-10-05 → 2005-10-06 A (+1d) | 3d → 1d | 0% → 100% | 212d → none | constraint start no earlier than 2005-10-02 → start no earlier than 2005-10-06; baseline start none → 2005-10-03; baseline finish none → 2005-10-05 |
| 9 | Podložni beton pod temelji in talno ploščo | 2005-10-04 → 2005-10-07 A (+3d) | 2005-10-10 → 2005-10-14 A (+4d) | 6d → 7d | 0% → 100% | 212d → none | was named Podložni beton pod temelji; baseline start none → 2005-10-04; baseline finish none → 2005-10-10 |
| 10 | Izdelava temeljev točkovnih in pasovnih, zasip za temelji | 2005-10-05 → 2005-10-12 A (+7d) | 2005-10-18 → 2005-10-19 A (+1d) | 12d → 7d | 0% → 100% | 202d → none | constraint start no earlier than 2005-01-17 → start no earlier than 2005-10-12; baseline start none → 2005-10-05; baseline finish none → 2005-10-18 |
| 11 | vgrajevanje tampona z utrjevanjem | 2005-10-08 → 2005-10-06 A (-2d) | 2005-10-19 → 2005-10-06 A (-13d) | 10d → 1d | 0% → 100% | 203d → none | baseline start none → 2005-10-08; baseline finish none → 2005-10-19 |
| 12 | KANALIZACIJA notranja, kinete, zasip | 2005-10-10 A | 2005-10-20 → 2005-10-14 A (-6d) | 10d → 5d | 0% → 100% | 203d → none | constraint none → start no earlier than 2005-10-10; baseline start none → 2005-10-10; baseline finish none → 2005-10-20 |
| 13 | TALNA PLOŠČA | 2005-10-11 → 2005-10-15 A (+4d) | 2005-10-21 → 2005-10-19 A (-2d) | 10d → 4d | 0% → 100% | 202d → none | constraint start no earlier than 2005-03-14 → start no earlier than 2005-10-08; baseline start none → 2005-10-11; baseline finish none → 2005-10-21 |
| 14 | **PRITLIČJE** | 2005-10-17 → 2005-10-22 A (+5d) | 2005-11-03 → 2005-11-19 A (+16d) | 14d → 23d | 0% → 100% | 66d → none | baseline start none → 2005-10-17; baseline finish none → 2005-11-03 |
| 15 | ab stene, stebri, vertikalne vezi | 2005-10-17 → 2005-10-27 A (+10d) | 2005-10-26 → 2005-11-17 A (+22d) | 9d → 17d | 0% → 100% | 134d → none | constraint start no earlier than 2005-10-17 → start no earlier than 2005-10-27; baseline start none → 2005-10-17; baseline finish none → 2005-10-26 |
| 16 | zidanje zidov | 2005-10-17 → 2005-10-22 A (+5d) | 2005-10-26 → 2005-11-12 A (+17d) | 9d → 16d | 0% → 100% | 198d → none | constraint start no earlier than 2005-06-18 → start no earlier than 2005-10-22; baseline start none → 2005-10-17; baseline finish none → 2005-10-26 |
| 17 | horizontalne vezi, preklade, pošča | 2005-10-24 → 2005-11-07 A (+14d) | 2005-11-03 → 2005-11-19 A (+16d) | 8d → 13d | 0% → 100% | 134d → none | constraint start no earlier than 2005-06-29 → start no earlier than 2005-11-07; baseline start none → 2005-10-24; baseline finish none → 2005-11-03 |
| 18 | **1. ETAŽA** | 2005-10-29 → 2005-11-17 A (+19d) | 2005-11-17 → 2005-12-06 A (+19d) | 15d → 17d | 0% → 100% | 66d → none | baseline start none → 2005-10-29; baseline finish none → 2005-11-17 |
| 19 | ab stene, stebri, vertikalne vezi | 2005-10-29 → 2005-11-21 A (+23d) | 2005-11-10 → 2005-12-02 A (+22d) | 9d → 11d | 0% → 100% | 134d → none | constraint none → start no earlier than 2005-11-19; baseline start none → 2005-10-29; baseline finish none → 2005-11-10 |
| 20 | zidanje zidov | 2005-10-29 → 2005-11-17 A (+19d) | 2005-11-10 → 2005-11-30 A (+20d) | 9d → 12d | 0% → 100% | 187d → none | constraint start no earlier than 2005-06-18 → start no earlier than 2005-11-17; baseline start none → 2005-10-29; baseline finish none → 2005-11-10 |
| 21 | horizontalne vezi, preklade, pošča | 2005-11-09 → 2005-11-24 A (+15d) | 2005-11-17 → 2005-12-06 A (+19d) | 8d → 11d | 0% → 100% | 134d → none | constraint none → start no earlier than 2005-11-23; baseline start none → 2005-11-09; baseline finish none → 2005-11-17 |
| 22 | VENEC NA STREHI | 2005-11-16 → 2005-12-07 A (+21d) | 2005-11-22 → 2005-12-12 A (+20d) | 6d → 5d | 0% → 100% | 134d → none | constraint none → start no earlier than 2005-12-07; baseline start none → 2005-11-16; baseline finish none → 2005-11-22 |
| 23 | Predelne stene | 2005-12-23 → 2006-01-13 A (+21d) | 2006-02-10 → 2006-02-03 A (-7d) | 36d → 19d | 0% → 100% | 115d → none | constraint start no earlier than 2005-12-23 → start no earlier than 2006-01-13; baseline start none → 2005-12-23; baseline finish none → 2006-02-10 |
| 24 | **OBJEKT 2** | 2005-10-06 → 2005-10-10 A (+4d) | 2006-02-15 → 2006-02-22 A (+7d) | 105d → 107d | 0% → 100% | 0d → none | baseline start none → 2005-10-06; baseline finish none → 2006-02-15 |
| 25 | **TEMELJI** | 2005-10-06 → 2005-10-10 A (+4d) | 2005-10-22 → 2005-10-26 A (+4d) |  | 0% → 100% | 15d → none | baseline start none → 2005-10-06; baseline finish none → 2005-10-22 |
| 26 | Izkop za temelje | 2005-10-06 → 2005-10-10 A (+4d) | 2005-10-08 → 2005-10-10 A (+2d) | 3d → 1d | 0% → 100% | 98d → none | constraint start no earlier than 2005-10-06 → start no earlier than 2005-10-10; baseline start none → 2005-10-06; baseline finish none → 2005-10-08 |
| 27 | Podložni beton pod temelji | 2005-10-07 → 2005-10-11 A (+4d) | 2005-10-13 → 2005-10-18 A (+5d) | 6d → 7d | 0% → 100% | 98d → none | constraint finish no earlier than 2004-12-08 → start no earlier than 2005-10-11; baseline start none → 2005-10-07; baseline finish none → 2005-10-13 |
| 28 | Izdelava temeljev točkovnih in pasovnih, zasip za temelji | 2005-10-08 → 2005-10-20 A (+12d) | 2005-10-21 → 2005-10-26 A (+5d) | 12d → 6d | 0% → 100% | 13d → none | constraint start no earlier than 2005-01-17 → start no earlier than 2005-10-20; baseline start none → 2005-10-08; baseline finish none → 2005-10-21 |
| 29 | vgrajevanje tampona z utrjevanjem | 2005-10-12 → 2005-10-24 A (+12d) | 2005-10-22 → 2005-10-24 A (+2d) | 10d → 0d | 0% → 100% | 89d → none | constraint start no earlier than 2005-05-16 → finish no earlier than 2005-10-08; baseline start none → 2005-10-12; baseline finish none → 2005-10-22 |
| 30 | KANALIZACIJA notranja, kinete, zasip | 2005-10-13 → 2005-10-12 A (-1d) | 2005-10-24 → 2005-10-18 A (-6d) | 10d → 6d | 0% → 100% | 89d → none | constraint none → start no earlier than 2005-10-12; baseline start none → 2005-10-13; baseline finish none → 2005-10-24 |
| 31 | TALNA PLOŠČA | 2005-10-14 → 2005-10-20 A (+6d) | 2005-10-25 → 2005-10-26 A (+1d) | 10d → 6d | 0% → 100% | 13d → none | constraint start no earlier than 2005-03-14 → start no earlier than 2005-10-17; baseline start none → 2005-10-14; baseline finish none → 2005-10-25 |
| 32 | **PRITLIČJE** | 2005-10-26 → 2005-11-15 A (+20d) | 2005-11-14 → 2005-12-19 A (+35d) | 15d → 30d | 0% → 100% | 13d → none | baseline start none → 2005-10-26; baseline finish none → 2005-11-14 |
| 33 | ab stene, stebri, vertikalne vezi | 2005-10-26 → 2005-12-02 A (+37d) | 2005-11-08 → 2005-12-16 A (+38d) | 10d → 13d | 0% → 100% | 13d → none | constraint start no earlier than 2005-10-17 → start no earlier than 2005-12-02; baseline start none → 2005-10-26; baseline finish none → 2005-11-08 |
| 34 | zidanje zidov | 2005-10-26 → 2005-11-15 A (+20d) | 2005-11-07 → 2005-12-07 A (+30d) | 9d → 20d | 0% → 100% | 79d → none | constraint start no earlier than 2005-06-18 → start no earlier than 2005-11-12; baseline start none → 2005-10-26; baseline finish none → 2005-11-07 |
| 35 | horizontalne vezi, preklade, pošča | 2005-11-05 → 2005-12-06 A (+31d) | 2005-11-14 → 2005-12-19 A (+35d) | 8d → 12d | 0% → 100% | 13d → none | constraint start no earlier than 2005-06-29 → start no earlier than 2005-12-01; baseline start none → 2005-11-05; baseline finish none → 2005-11-14 |
| 36 | **1. ETAŽA** | 2005-11-11 → 2005-12-14 A (+33d) | 2006-01-26 → 2006-01-27 A (+1d) | 59d → 31d | 0% → 100% | 13d → none | baseline start none → 2005-11-11; baseline finish none → 2006-01-26 |
| 37 | ab stene, stebri, vertikalne vezi | 2005-11-11 → 2005-12-17 A (+36d) | 2005-11-21 → 2006-01-19 A (+59d) | 9d → 21d | 0% → 100% | 13d → none | constraint none → finish no earlier than 2006-01-19; baseline start none → 2005-11-11; baseline finish none → 2005-11-21 |
| 38 | zidanje zidov | 2005-11-11 → 2005-12-14 A (+33d) | 2005-11-21 → 2006-01-18 A (+58d) | 9d → 23d | 0% → 100% | 67d → none | constraint start no earlier than 2005-06-18 → start no earlier than 2005-12-14; baseline start none → 2005-11-11; baseline finish none → 2005-11-21 |
| 39 | horizontalne vezi, preklade, pošča | 2005-11-19 → 2005-12-20 A (+31d) | 2006-01-26 → 2006-01-27 A (+1d) | 8d → 26d | 0% → 100% | 13d → none | constraint none → start no earlier than 2005-12-20; baseline start none → 2005-11-19; baseline finish none → 2006-01-26 |
| 40 | VENEC NA STREHI | 2006-01-31 → 2006-01-28 A (-3d) | 2006-02-06 → 2006-02-01 A (-5d) | 6d → 4d | 0% → 100% | 8d → none | constraint start no earlier than 2006-01-31 → start no earlier than 2006-01-28; baseline start none → 2006-01-31; baseline finish none → 2006-02-06 |
| 41 | Predelne stene | 2006-01-16 → 2006-02-06 A (+21d) | 2006-02-15 → 2006-02-22 A (+7d) | 27d → 15d | 0% → 100% | 0d → none | constraint start no earlier than 2006-01-16 → start no earlier than 2006-02-06; baseline start none → 2006-01-16; baseline finish none → 2006-02-15 |
